# PROGRAMACION CERCADO 120

Schedule from MS Project, 2022-08-01 to 2022-11-28, costs in S..

## Calendars

- Estándar: Mon-Sun 08:00-13:00, 14:00-17:00.

## Schedule

| ID | WBS | Task | Type | Duration | Start | Finish | Predecessors | Total slack | Free slack | Cost | Text1 |
| --- | --- | --- | --- | --- | --- | --- | --- | --- | --- | --- | --- |
| 1 | 1 | **"RECONSTRUCCIÓN DE PISTAS DE LA CALLE JORGE HERRERA ENTRE LA CALLE MAYOR NOVOA Y 24 DE JULIO, CALLE MAYOR NOVOA ENTRE LA CALLE BOLIVAR Y FRANCISCO NAVARRETE; DEL CERCADO DE TUMBES - DISTRITO TUMBES - PROVINCIA TUMBES Y REGION DE TUMBES"** |  | 120d | 2022-08-01 | 2022-11-28 |  | 0d |  | 1,750,345.48 |  |
| 2 | 1.1 | INICIO DEL PROYECTO | milestone | 0d | 2022-08-01 | 2022-08-01 |  | 0d |  |  |  |
| 3 | 1.2 | **PAVIMENTO RIGIDO** |  | 120d | 2022-08-01 | 2022-11-28 |  | 0d |  | 913,453.4 | 01 |
| 4 | 1.2.1 | **OBRAS PROVISIONALES** |  | 110d | 2022-08-01 | 2022-11-18 |  | 0d |  | 65,072.47 | 01.01 |
| 5 | 1.2.1.1 | SUMINISTRO Y COLOCACION DE CARTEL DE OBRA (5.60x3.40m) |  | 1d | 2022-08-01 | 2022-08-01 | 2SS | 105d | 0d | 1,184.8 | 01.01.01 |
| 6 | 1.2.1.2 | CASETA PARA ALMACEN, OFICINA Y GUARDIANIA |  | 1d | 2022-08-01 | 2022-08-01 | 5SS | 119d |  | 4,666.5 | 01.01.02 |
| 7 | 1.2.1.3 | MANTENIMIENTO DEL TRANSITO Y SEGURIDAD VIAL |  | 110d | 2022-08-01 | 2022-11-18 | 2SS | 0d |  | 9,803.76 | 01.01.03 |
| 8 | 1.2.1.4 | PLAN DE MONITOREO DE IMPACTO AMBIENTAL |  | 110d | 2022-08-01 | 2022-11-18 | 7SS | 0d |  | 24,302.95 | 01.01.04 |
| 9 | 1.2.1.5 | **ELABORACION, IMPLEMENTACION Y ADMINISTRACION DEL PLAN DE SEGURIDAD Y SALUD EN EL TRABAJO** |  | 110d | 2022-08-01 | 2022-11-18 |  | 0d |  | 25,114.46 | 01.01.05 |
| 10 | 1.2.1.5.1 | EQUIPO DE PROTECCION COLECCTIVA |  | 110d | 2022-08-01 | 2022-11-18 | 8SS | 10d |  | 4,022.6 | 01.01.05.01 |
| 11 | 1.2.1.5.2 | EQUIPO DE PROTECCION INDIVIDUAL |  | 110d | 2022-08-01 | 2022-11-18 | 8SS | 0d |  | 11,519 | 01.01.05.02 |
| 12 | 1.2.1.5.3 | **PLAN PARA LA PREVENCION Y CONTROL ANTE LA COVID-19 EN OBRA** |  | 110d | 2022-08-01 | 2022-11-18 |  | 0d |  | 9,572.86 | 01.01.05.03 |
| 13 | 1.2.1.5.3.1 | EQUIPO DE PROTECCION INDIVIDUAL PARA PERSONAL DE OBRA |  | 110d | 2022-08-01 | 2022-11-18 | 11SS | 0d |  | 1,008 | 01.01.05.03.01 |
| 14 | 1.2.1.5.3.2 | EQUIPO DE PROTECCION INDIVIDUAL PARA DIRECCION DE OBRA |  | 110d | 2022-08-01 | 2022-11-18 | 13SS | 0d |  | 336 | 01.01.05.03.02 |
| 15 | 1.2.1.5.3.3 | EQUIPO DE PROTECCION INDIVIDUAL PARA PERSONAL DE SALUD |  | 110d | 2022-08-01 | 2022-11-18 | 14SS | 0d |  | 1,090.4 | 01.01.05.03.03 |
| 16 | 1.2.1.5.3.4 | KIT PARA LAVADO Y DESINFECCION DE PERSONAL |  | 110d | 2022-08-01 | 2022-11-18 | 15SS | 0d |  | 1,108.8 | 01.01.05.03.04 |
| 17 | 1.2.1.5.3.5 | EQUIPAMIENTO PARA VIGILANCIA DE LA SALUD DEL TRABAJADOR |  | 110d | 2022-08-01 | 2022-11-18 | 16SS | 0d |  | 3,150.9 | 01.01.05.03.05 |
| 18 | 1.2.1.5.3.6 | IMPLEMENTACION DE AREA DE TRIAJE (CONTROL PREVIO) |  | 110d | 2022-08-01 | 2022-11-18 | 17SS | 0d |  | 2,878.76 | 01.01.05.03.06 |
| 19 | 1.2.2 | **TRABAJOS PRELIMINARES** |  | 110d | 2022-08-01 | 2022-11-18 |  | 0d |  | 50,587.72 | 01.02 |
| 20 | 1.2.2.1 | TRAZO, NIVELACION Y REPLANTEO |  | 110d | 2022-08-01 | 2022-11-18 | 18SS | 0d |  | 7,644.02 | 01.02.01 |
| 21 | 1.2.2.2 | MOVILIZACION Y DESMOVILIZACION DE EQUIPO |  | 110d | 2022-08-01 | 2022-11-18 | 20SS | 0d |  | 7,760 | 01.02.02 |
| 22 | 1.2.2.3 | **DEMOLICIONES** |  | 15d | 2022-08-03 | 2022-08-17 |  | 0d |  | 35,183.7 | 01.02.03 |
| 23 | 1.2.2.3.1 | DEMOLICION DE PAVIMENTO EXISTENTE EN MAL ESTADO. |  | 15d | 2022-08-03 | 2022-08-17 | 21SS+2d | 0d |  | 32,071.46 | 01.02.03.01 |
| 24 | 1.2.2.3.2 | EXTRACCION DE ADOQUIN DE CONCRETO EXISTENTE MANUAL |  | 6d | 2022-08-03 | 2022-08-08 | 23SS | 0d |  | 3,112.24 | 01.02.03.02 |

| ID | WBS | Task | Duration | Start | Finish | Predecessors | Total slack | Free slack | Constraint | Cost | Text1 |
| --- | --- | --- | --- | --- | --- | --- | --- | --- | --- | --- | --- |
| 25 | 1.2.3 | **PAVIMENTACION** | 116d | 2022-08-05 | 2022-11-28 |  | 0d |  |  | 772,744.3 | 01.03 |
| 26 | 1.2.3.1 | **MOVIMIENTO DE TIERRAS** | 91d | 2022-08-05 | 2022-11-03 |  | 0d |  |  | 259,356.96 | 01.03.01 |
| 27 | 1.2.3.1.1 | CORTE CON MAQUINARIA PARA CONFORMACION DE ESTRUCTURA DE PAVIMENTO | 7d | 2022-08-05 | 2022-08-11 | 24SS+2d | 0d |  |  | 19,940.02 | 01.03.01.01 |
| 28 | 1.2.3.1.2 | EXCAVACION MANUAL P/ SARDINEL SUMERGIDO EN LOSA EN PAVIMENTO | 4d | 2022-10-30 | 2022-11-02 | 33SS | 26d |  |  | 453.51 | 01.03.01.02 |
| 29 | 1.2.3.1.3 | PERFILADO Y COMPACTACION DE SUB RASANTE EN PAVIMENTO | 7d | 2022-08-07 | 2022-08-13 | 27SS+2d | 107d |  | start no earlier than 2022-08-06 | 14,573.64 | 01.03.01.03 |
| 30 | 1.2.3.1.4 | MEJORAMIENTO DE SUB RASANTE CON MATERIAL DE PRESTAMO OVER DE 6" A 8" E=0.30M | 5d | 2022-10-21 | 2022-10-25 | 182FS-12d | 0d |  |  | 71,266.17 | 01.03.01.04 |
| 31 | 1.2.3.1.5 | MEJORAMIENTO DE SUB RASANTE CON MATERIAL DE PRESTAMO HORMIGON GRUESO E=0.20M | 5d | 2022-10-23 | 2022-10-27 | 30SS+2d | 0d |  |  | 31,720.95 | 01.03.01.05 |
| 32 | 1.2.3.1.6 | SUMINISTRO E INSTALACION DE GEOTEXTIL NO TEJIDO 270 GR/M2 | 5d | 2022-10-28 | 2022-11-01 | 31 | 0d |  |  | 13,670.39 | 01.03.01.06 |
| 33 | 1.2.3.1.7 | COLOCACION, CONFORMACION Y COMPACTACION DE SUB BASE (50% AFIRMADO + 50% HORMIGON ) E=0.20M | 5d | 2022-10-30 | 2022-11-03 | 32SS+2d | 0d |  |  | 59,080.38 | 01.03.01.07 |
| 34 | 1.2.3.1.8 | ELIMINACIÓN DE MATERIAL EXCEDENTE D. PROM 5 KM DE LA OBRA | 8d | 2022-08-10 | 2022-08-17 | 27SS+5d | 103d |  |  | 48,651.9 | 01.03.01.08 |
| 35 | 1.2.3.2 | **PAVIMENTO RIGIDO** | 23d | 2022-11-03 | 2022-11-25 |  | 0d |  |  | 382,129.65 | 01.03.02 |
| 36 | 1.2.3.2.1 | LOSA DE RODADURA, CONCRETO F`C=280 Kg/cm2, e=0.20 m.- CEMENTO TIPO MS | 10d | 2022-11-08 | 2022-11-17 | 37SS+5d | 0d |  |  | 365,555.41 | 01.03.02.01 |
| 37 | 1.2.3.2.2 | ENCOFRADO Y DESENCOFRADO DE LOSA DE RODADURA | 10d | 2022-11-03 | 2022-11-12 | 33FS-1d | 0d |  |  | 1,115.5 | 01.03.02.02 |
| 38 | 1.2.3.2.3 | UÑA EN TERMINO DE LOSA DE 0.20X0.50m CONCRETO F'C=280 KG/CM2 | 10d | 2022-11-08 | 2022-11-17 | 36SS | 11d |  |  | 5,921.58 | 01.03.02.03 |
| 39 | 1.2.3.2.4 | CURADO DE LOSA DE RODADURA | 18d | 2022-11-08 | 2022-11-25 | 36SS | 0d |  |  | 9,537.16 | 01.03.02.04 |
| 40 | 1.2.3.3 | **JUNTAS** | 21d | 2022-11-08 | 2022-11-28 |  | 0d |  |  | 117,964.1 | 01.03.03 |
| 41 | 1.2.3.3.1 | CORTE Y SELLADO DE JUNTAS DE CONTRACCIÓN e= 6mm | 10d | 2022-11-18 | 2022-11-27 | 39FS-8d | 0d |  |  | 34,858.64 | 01.03.03.01 |
| 42 | 1.2.3.3.2 | JUNTA TRANSVERSAL CON DOWEL LISO H=10CM - VARILLA LISA Ø 1" X 41CM @ 30CM INC/ CANASTILLA ELECTROSOLDADA | 8d | 2022-11-08 | 2022-11-15 | 36SS | 13d | 0d |  | 62,198.64 | 01.03.03.02 |
| 43 | 1.2.3.3.3 | JUNTA LONGITUDINAL- BARRA DE AMARRE CORRUGADA Ø 1/2"X95CM @ 76CM INC/ CANASTILLA ELECTROSOLDADA | 8d | 2022-11-08 | 2022-11-15 | 42SS | 13d |  |  | 14,843.97 | 01.03.03.03 |
| 44 | 1.2.3.3.4 | JUNTA DE CONSTRUCCION ASFALTICA E=1" | 4d | 2022-11-25 | 2022-11-28 | 52FS-4d | 0d |  |  | 6,062.85 | 01.03.03.04 |
| 45 | 1.2.3.4 | **SEÑALIZACION HORIZONTAL EN PAVIMENTO** | 5d | 2022-11-24 | 2022-11-28 |  | 0d |  |  | 13,293.59 | 01.03.04 |
| 46 | 1.2.3.4.1 | PINTADO DE FRANJAS EN PAVIMENTO | 5d | 2022-11-24 | 2022-11-28 | 44SS-1d | 0d |  |  | 201.24 | 01.03.04.02 |
| 47 | 1.2.3.4.2 | PINTADO DE LINEAS DE PASO PEATONAL | 5d | 2022-11-24 | 2022-11-28 | 46SS | 0d |  |  | 3,662.26 | 01.03.04.03 |
| 48 | 1.2.3.4.3 | PINTADO DE LINEAS DE PARE | 5d | 2022-11-24 | 2022-11-28 | 46SS | 0d |  |  | 923.72 | 01.03.04.03 |
| 49 | 1.2.3.4.4 | PINTADO DE FLECHAS DIRECCIONALES SEGUN TIPO | 5d | 2022-11-24 | 2022-11-28 | 46SS | 0d |  |  | 903.36 | 01.03.04.03 |
| 50 | 1.2.3.4.5 | PINTADO DE SARDINEL DE BORDE DE VEREDA EXISTENTE COLOR AMARILLO | 5d | 2022-11-24 | 2022-11-28 | 46SS | 0d |  |  | 7,603.01 | 01.03.04.03 |

| ID | WBS | Task | Duration | Start | Finish | Predecessors | Total slack | Free slack | Cost | Text1 |
| --- | --- | --- | --- | --- | --- | --- | --- | --- | --- | --- |
| 51 | 1.2.4 | **TRABAJOS COMPLEMENTARIOS** | 120d | 2022-08-01 | 2022-11-28 |  | 0d |  | 25,048.91 | 01.04 |
| 52 | 1.2.4.1 | LIMPIEZA FINAL GENERAL DE LA OBRA | 3d | 2022-11-26 | 2022-11-28 | 41FS-2d | 0d |  | 2,036.02 | 01.04.01 |
| 53 | 1.2.4.2 | BOMBEO DE AGUA PROVINIENTE DE NIVEL FREATICO | 7d | 2022-08-05 | 2022-08-11 | 27SS | 109d |  | 13,225.2 | 01.04.02 |
| 54 | 1.2.4.3 | TRANSPORTE DE MATERIALES A OBRA | 15d | 2022-08-01 | 2022-08-15 | 5SS | 105d |  | 9,787.69 | 01.04.03 |
| 55 | 1.3 | **REDES DE AGUA Y ALCANTARILLADO** | 92d | 2022-08-05 | 2022-11-04 |  | 0d |  | 836,892.08 | 02 |
| 56 | 1.3.1 | **TRABAJOS PRELIMINARES** | 90d | 2022-08-05 | 2022-11-02 |  | 0d |  | 82,732.13 | 02.01 |
| 57 | 1.3.1.1 | TRAZO Y REPLANTEO INICIAL DEL PROYECTO, PARA LÍNEAS-REDES | 90d | 2022-08-05 | 2022-11-02 | 27SS | 0d |  | 2,243.39 | 02.01.01 |
| 58 | 1.3.1.2 | CERCO DE MALLA HDP DE 1 M ALTURA PARA LÍMITE DE SEGURIDAD DE OBRA | 90d | 2022-08-05 | 2022-11-02 | 57SS | 0d |  | 3,956.93 | 02.01.02 |
| 59 | 1.3.1.3 | CONO FIBRA VIDRIO FOSFORESCENTE P/DESVÍO DE TRÁNSITO S/D (PROV. DURANTE OBRA) | 90d | 2022-08-05 | 2022-11-02 | 58SS | 0d |  | 450.8 | 02.01.03 |
| 60 | 1.3.1.4 | TRANQUERA TIPO TIJERA DE 2,40 X 1,20 M PARA SEÑAL PELIGRO (PROV. DURANTE OBRA) | 90d | 2022-08-05 | 2022-11-02 | 59SS | 0d |  | 3,368.33 | 02.01.04 |
| 61 | 1.3.1.5 | PUENTE DE MADERA PARA PASE PEATONAL SOBRE ZANJA S/D (PROV. DURANTE OBRA) | 90d | 2022-08-05 | 2022-11-02 | 60SS | 0d |  | 4,046 | 02.01.05 |
| 62 | 1.3.1.6 | PUENTE DE MADERA PARA PASE VEHICULAR SOBRE ZANJA S/D (PROV. DURANTE OBRA) | 90d | 2022-08-05 | 2022-11-02 | 61SS | 0d |  | 7,352.96 | 02.01.06 |
| 63 | 1.3.1.7 | SUMINISTRO E INSTALACIÓN DE TUBERÍA PROVISIONAL DE PVC-U UF NTP ISO 1452 PN 7.5 DN 250 MM (INCL. ANILLO +2% DESPERDICIOS), PARA NO INTERRUMPIR SERVICIO DE AGUA | 90d | 2022-08-05 | 2022-11-02 | 62SS | 26d | 0d | 48,025.86 | 02.01.07 |
| 64 | 1.3.1.8 | COLOCACION DE TUBERIA DE PVC-Ø4" SAL PROVISIONAL DE ALCANTARILLADO PARA CONTINUIDAD DEL SERVICIO | 90d | 2022-08-05 | 2022-11-02 | 63SS | 26d |  | 13,287.86 | 02.01.08 |
| 65 | 1.3.2 | **RED DE AGUA POTABLE** | 72d | 2022-08-25 | 2022-11-04 |  | 24d |  | 338,719.64 | 02.02 |
| 66 | 1.3.2.1 | **MOVIMIENTO DE TIERRAS** | 67d | 2022-08-25 | 2022-10-30 |  | 24d |  | 147,953.78 | 02.02.01 |
| 67 | 1.3.2.1.1 | **EXCAVACION DE ZANJAS** | 20d | 2022-08-25 | 2022-09-13 |  | 24d |  | 9,019 | 02.02.01.01 |
| 68 | 1.3.2.1.1.1 | EXCAV. ZANJA(MÁQ)P/TUB T-SATURADO DN 90MM DE 1,50 M PROF. | 20d | 2022-08-25 | 2022-09-13 | 135FS-1d | 24d | 0d | 3,776.5 | 02.02.01.01.01 |
| 69 | 1.3.2.1.1.2 | EXCAV. ZANJA(MÁQ)P/TUB T-NORMAL DN 160-315MM DE 1,50 M PROF. | 20d | 2022-08-25 | 2022-09-13 | 68SS | 76d | 0d | 5,242.5 | 02.02.01.01.02 |
| 70 | 1.3.2.1.2 | **REFINE Y CONFORMACIÓN DE ZANJAS** | 20d | 2022-08-25 | 2022-09-13 |  | 42d |  | 10,922.35 | 02.02.01.02 |
| 71 | 1.3.2.1.2.1 | REFINE Y NIVEL DE ZANJA T-SATURADO P/TUB. DN 90MM PARA TODA PROF. | 20d | 2022-08-25 | 2022-09-13 | 68SS | 42d | 0d | 1,249.15 | 02.02.01.02.01 |
| 72 | 1.3.2.1.2.2 | REFINE Y NIVEL DE ZANJA T-NORMAL P/TUB. DN 160-315MM PARA TODA PROF. | 20d | 2022-08-25 | 2022-09-13 | 69SS | 76d |  | 2,834.83 | 02.02.01.02.02 |
| 73 | 1.3.2.1.2.3 | DRENAJE DE ZANJAS C/BOMBEO P/DEPRIMIR NAPA FREÁTICA | 20d | 2022-08-25 | 2022-09-13 | 71SS | 42d | 0d | 6,838.37 | 02.02.01.02.03 |
| 74 | 1.3.2.1.3 | **ENTIBADO DE ZANJAS** | 20d | 2022-08-25 | 2022-09-13 |  | 76d |  | 16,706.66 | 02.02.01.03 |
| 75 | 1.3.2.1.3.1 | ENTIBADO DE ZANJA DE 2.01 HASTA 2.50 m | 20d | 2022-08-25 | 2022-09-13 | 71SS | 76d |  | 16,706.66 | 02.02.01.03.01 |

| ID | WBS | Task | Duration | Start | Finish | Predecessors | Total slack | Free slack | Cost | Text1 |
| --- | --- | --- | --- | --- | --- | --- | --- | --- | --- | --- |
| 76 | 1.3.2.1.4 | **CAMA DE APOYO PARA PROTECCION DE TUBERIAS** | 35d | 2022-09-13 | 2022-10-17 |  | 42d |  | 41,433.5 | 02.02.01.04 |
| 77 | 1.3.2.1.4.1 | CAMA DE OVER E=0.30 ZANJA P/TUB DN 90MM | 6d | 2022-09-13 | 2022-09-18 | 73FS-1d | 42d | 0d | 14,417.52 | 02.02.01.04.01 |
| 78 | 1.3.2.1.4.2 | CAPA DE HORMIGON E=0.20 ZANJA P/TUB DN 90MM | 6d | 2022-09-13 | 2022-09-18 | 77SS | 42d | 0d | 6,751.22 | 02.02.01.04.02 |
| 79 | 1.3.2.1.4.3 | CAMA DE ARENA E=0.10M. ZANJA P/TUB DN 90-315MM | 6d | 2022-09-18 | 2022-09-23 | 78FS-1d | 42d | 0d | 6,769.94 | 02.02.01.04.03 |
| 80 | 1.3.2.1.4.4 | CAMA DE ARENA E=0.20 SCT P/TUBERÍA DN 90-315MM | 8d | 2022-10-10 | 2022-10-17 | 96FS-1d | 42d |  | 13,494.82 | 02.02.01.04.04 |
| 81 | 1.3.2.1.5 | **RELLENO, APISONADO Y COMPACTACION ZANJAS** | 20d | 2022-10-11 | 2022-10-30 |  | 24d |  | 47,087.09 | 02.02.01.05 |
| 82 | 1.3.2.1.5.1 | RELLENO C/MATERIAL DE PRÉSTAMO DN 90-315MM. 1,50 M PROF. | 20d | 2022-10-11 | 2022-10-30 | 114FS+3d | 24d | 0d | 47,087.09 | 02.02.01.05.01 |
| 83 | 1.3.2.1.6 | **ACARREO Y ELIMINACION MATERIAL EXCEDENTE** | 15d | 2022-09-09 | 2022-09-23 |  | 66d |  | 22,785.18 | 02.02.01.06 |
| 84 | 1.3.2.1.6.1 | ACARREO INTERNO, MATERIAL PROCEDEDENTE DE LAS EXCAVACIONES EN ZONA ALEDAÑA | 15d | 2022-09-09 | 2022-09-23 | 68FS-5d | 66d | 0d | 11,148.82 | 02.02.01.06.01 |
| 85 | 1.3.2.1.6.2 | ELIMINACIÓN DE MATERIAL EXCEDENTE D. PROM 5 KM DE LA OBRA | 15d | 2022-09-09 | 2022-09-23 | 84SS | 66d |  | 11,636.36 | 02.02.01.06.02 |
| 86 | 1.3.2.2 | **SUMINISTRO E INSTALACION DE TUBERIA** | 20d | 2022-09-19 | 2022-10-08 |  | 42d |  | 90,268.79 | 02.02.02 |
| 87 | 1.3.2.2.1 | TUBERÍA DE PVC-U UF NTP ISO 1452 PN 10 DN 90MM INCL. ANILLO + 2% DESPERDICIOS | 20d | 2022-09-19 | 2022-10-08 | 79SS+1d | 42d | 0d | 6,905.19 | 02.02.02.01 |
| 88 | 1.3.2.2.2 | TUBERÍA DE PVC-U UF NTP ISO 1452 PN 10 DN 160MM INCL. ANILLO + 2% DESPERDICIOS | 20d | 2022-09-19 | 2022-10-08 | 87SS | 42d | 0d | 10,764.97 | 02.02.02.02 |
| 89 | 1.3.2.2.3 | TUBERÍA DE PVC-U UF NTP ISO 1452 PN 10 DN 315MM INCL. ANILLO + 2% DESPERDICIOS | 20d | 2022-09-19 | 2022-10-08 | 88SS | 42d | 0d | 68,806.53 | 02.02.02.03 |
| 90 | 1.3.2.2.4 | INSTALACIÓN DE TUBERÍA PVC P/AGUA POTAB. DN 90MM NTP 1452 | 20d | 2022-09-19 | 2022-10-08 | 89SS | 42d | 0d | 984.8 | 02.02.02.04 |
| 91 | 1.3.2.2.5 | INSTALACIÓN DE TUBERÍA PVC P/AGUA POTAB. DN 160MM NTP 1452 | 20d | 2022-09-19 | 2022-10-08 | 90SS | 50d | 0d | 967.14 | 02.02.02.05 |
| 92 | 1.3.2.2.6 | INSTALACIÓN DE TUBERÍA PVC P/AGUA POTAB. DN 315MM NTP 1452 | 20d | 2022-09-19 | 2022-10-08 | 91SS | 50d | 0d | 1,840.16 | 02.02.02.06 |
| 93 | 1.3.2.3 | **PRUEBAS HIDRAULICAS** | 4d | 2022-10-07 | 2022-10-10 |  | 42d |  | 7,413.96 | 02.02.03 |
| 94 | 1.3.2.3.1 | PRUEBA HIDRÁULICA Y DESINFECCIÓN DE TUBERÍA AGUA POTAB. DN 90MM NTP ISO 1452 PN 10 | 4d | 2022-10-07 | 2022-10-10 | 90FS-2d | 42d | 0d | 2,570.93 | 02.02.03.01 |
| 95 | 1.3.2.3.2 | PRUEBA HIDRÁULICA Y DESINFECCIÓN DE TUBERÍA AGUA POTAB. DN 160MM NTP ISO 1452 PN 10 | 4d | 2022-10-07 | 2022-10-10 | 94SS | 42d | 0d | 1,827.41 | 02.02.03.02 |
| 96 | 1.3.2.3.3 | PRUEBA HIDRÁULICA Y DESINFECCIÓN DE TUBERÍA AGUA POTAB. DN 315MM NTP ISO 1452 PN 10 | 4d | 2022-10-07 | 2022-10-10 | 95SS | 42d | 0d | 3,015.62 | 02.02.03.03 |
| 97 | 1.3.2.4 | **SUMINISTRO E INSTALACION DE ACCESORIOS** | 20d | 2022-09-20 | 2022-10-09 |  | 50d |  | 6,055.35 | 02.02.04 |
| 98 | 1.3.2.4.1 | TEE REDUC. DE PVC - U UNIÓN FLEXIBLE NTP ISO 1452 PN 10 - DN 90X75MM | 20d | 2022-09-20 | 2022-10-09 | 92SS+1d | 50d | 0d | 101.1 | 02.02.04.01 |
| 99 | 1.3.2.4.2 | TEE REDUC. DE PVC - U UNIÓN FLEXIBLE NTP ISO 1452 PN 10 - DN 160X75MM | 20d | 2022-09-20 | 2022-10-09 | 98SS | 50d | 0d | 443.95 | 02.02.04.02 |
| 100 | 1.3.2.4.3 | TEE REDUC. DE PVC - U UNIÓN FLEXIBLE NTP ISO 1452 PN 10 - DN 160X110MM | 20d | 2022-09-20 | 2022-10-09 | 99SS | 50d | 0d | 444.9 | 02.02.04.03 |
| 101 | 1.3.2.4.4 | TEE REDUC. DE PVC - U UNIÓN FLEXIBLE NTP ISO 1452 PN 10 - DN 315X160MM | 20d | 2022-09-20 | 2022-10-09 | 100SS | 50d | 0d | 1,412.1 | 02.02.04.04 |
| 102 | 1.3.2.4.5 | CODO DE PVC-U UNIÓN FLEXIBLE NTP ISO 1452 PN 10 DE 90° DN 160MM | 20d | 2022-09-20 | 2022-10-09 | 101SS | 50d | 0d | 322.95 | 02.02.04.05 |
| 103 | 1.3.2.4.6 | CODO DE PVC-U UNIÓN FLEXIBLE NTP ISO 1452 PN 10 DE 11.25° DN 315MM | 20d | 2022-09-20 | 2022-10-09 | 102SS | 50d | 0d | 1,891.65 | 02.02.04.06 |
| 104 | 1.3.2.4.7 | INSTALACIÓN DE ACCESORIOS DE PVC-U UF - DN 90 - 315MM | 20d | 2022-09-20 | 2022-10-09 | 103SS | 50d | 0d | 453.1 | 02.02.04.07 |
| 105 | 1.3.2.4.8 | CONCRETO F'C=140 KG/CM2 PARA ANCLAJES DE ACCESORIOS DN 90 - 315MM. | 20d | 2022-09-20 | 2022-10-09 | 104SS | 50d | 0d | 985.6 | 02.02.04.08 |

| ID | WBS | Task | Duration | Start | Finish | Predecessors | Total slack | Free slack | Cost | Text1 |
| --- | --- | --- | --- | --- | --- | --- | --- | --- | --- | --- |
| 106 | 1.3.2.5 | **SUMINISTRO E INSTALACION DE VALVULAS** | 20d | 2022-09-20 | 2022-10-09 |  | 50d |  | 5,344.97 | 02.02.05 |
| 107 | 1.3.2.5.1 | VÁLVULA CPTA.CC, HO. DÚCTIL CIERRE ELÁST. VÁSTAGO ACERO INOXIDABLE DN 90MM | 20d | 2022-09-20 | 2022-10-09 | 105SS | 50d | 0d | 691.3 | 02.02.05.01 |
| 108 | 1.3.2.5.2 | VÁLVULA CPTA.CC, HO. DÚCTIL CIERRE ELÁST. VÁSTAGO ACERO INOXIDABLE DN 160MM | 20d | 2022-09-20 | 2022-10-09 | 107SS | 50d | 0d | 1,290.5 | 02.02.05.02 |
| 109 | 1.3.2.5.3 | VÁLVULA CPTA.CC, HO. DÚCTIL CIERRE ELÁST. VÁSTAGO ACERO INOXIDABLE DN 315MM | 20d | 2022-09-20 | 2022-10-09 | 108SS | 50d | 0d | 1,652.55 | 02.02.05.03 |
| 110 | 1.3.2.5.4 | INSTALACIÓN DE VÁLVULA COMPUERTA DN 90 MM INCL. REGISTRO | 20d | 2022-09-20 | 2022-10-09 | 109SS | 50d | 0d | 610.08 | 02.02.05.04 |
| 111 | 1.3.2.5.5 | INSTALACIÓN DE VÁLVULA COMPUERTA DN 160 MM INCL. REGISTRO | 20d | 2022-09-20 | 2022-10-09 | 110SS | 50d | 0d | 689.54 | 02.02.05.05 |
| 112 | 1.3.2.5.6 | INSTALACIÓN DE VÁLVULA COMPUERTA DN 315 MM INCL. REGISTRO | 20d | 2022-09-20 | 2022-10-09 | 111SS | 50d |  | 411 | 02.02.05.06 |
| 113 | 1.3.2.6 | **CONEXIONES DOMICILIARIAS DE AGUA** | 10d | 2022-09-28 | 2022-10-07 |  | 24d |  | 62,397.24 | 02.02.06 |
| 114 | 1.3.2.6.1 | CONEXIONES DOMICILIARIAS PARA AGUA POTABLE TUB. HDP DN 15 - 90MM. | 10d | 2022-09-28 | 2022-10-07 | 118SS+15d | 24d | 0d | 39,765.75 | 02.02.06.01 |
| 115 | 1.3.2.6.2 | CONEXIONES DOMICILIARIAS PARA AGUA POTABLE TUB. HDP DN 15 - 160MM. | 10d | 2022-09-28 | 2022-10-07 | 114SS | 52d |  | 22,631.49 | 02.02.06.02 |
| 116 | 1.3.2.7 | **RETIRO Y REPOSICION DE CONEXION DOMICILIARIA DE AGUA POTABLE** | 53d | 2022-09-13 | 2022-11-04 |  | 24d |  | 14,469.83 | 02.02.07 |
| 117 | 1.3.2.7.1 | CORTE DE VEREDA P/CONEXIÓN DOMICILIARIA | 6d | 2022-09-13 | 2022-09-18 | 68FS-1d | 24d | 0d | 3,336.62 | 02.02.07.01 |
| 118 | 1.3.2.7.2 | DEMOLICIÓN DE VEREDA P/CONEXIÓN DOMICILIARIA | 6d | 2022-09-13 | 2022-09-18 | 117SS | 24d | 0d | 1,010.59 | 02.02.07.02 |
| 119 | 1.3.2.7.3 | RETIRO DE CAJA DOMICILIARIA EXISTENTE (TAPA, CUERPO Y BASAE) | 6d | 2022-09-13 | 2022-09-18 | 118SS | 71d |  | 3,201.6 | 02.02.07.03 |
| 120 | 1.3.2.7.4 | CONCRETO F'C 175 kg/cm2 PARA VEREDAS E=10cm. (CEMENTO MS) | 10d | 2022-10-26 | 2022-11-04 | 82FS-5d | 24d |  | 6,921.02 | 02.02.07.04 |
| 121 | 1.3.2.8 | **EMPALMES A RED EXISTENTES Y OTROS** | 20d | 2022-09-19 | 2022-10-08 |  | 51d |  | 4,815.72 | 02.02.08 |
| 122 | 1.3.2.8.1 | EMPALME C/ INSERCIÓN DE TUBERÍA A LÍNEAS DE AGUA POTABLE DN 75MM | 20d | 2022-09-19 | 2022-10-08 | 87SS | 51d | 0d | 657.99 | 02.02.08.01 |
| 123 | 1.3.2.8.2 | EMPALME C/ INSERCIÓN DE TUBERÍA A LÍNEAS DE AGUA POTABLE DN 90MM | 20d | 2022-09-19 | 2022-10-08 | 122SS | 51d | 0d | 227.69 | 02.02.08.02 |
| 124 | 1.3.2.8.3 | EMPALME C/ INSERCIÓN DE TUBERÍA A LÍNEAS DE AGUA POTABLE DN 110MM | 20d | 2022-09-19 | 2022-10-08 | 123SS | 51d | 0d | 302.63 | 02.02.08.03 |
| 125 | 1.3.2.8.4 | EMPALME C/ INSERCIÓN DE TUBERÍA A LÍNEAS DE AGUA POTABLE DN 160MM | 20d | 2022-09-19 | 2022-10-08 | 124SS | 51d | 0d | 395.03 | 02.02.08.04 |
| 126 | 1.3.2.8.5 | EMPALME C/ INSERCIÓN DE TUBERÍA A LÍNEAS DE AGUA POTABLE DN 315MM | 20d | 2022-09-19 | 2022-10-08 | 125SS | 51d |  | 3,232.38 | 02.02.08.05 |
| 127 | 1.3.3 | **RED DE ALCANTARILLADO** | 89d | 2022-08-05 | 2022-11-01 |  | 1d |  | 415,440.31 | 02.03 |
| 128 | 1.3.3.1 | **MOVIMIENTO DE TIERRAS** | 86d | 2022-08-06 | 2022-10-30 |  | 0d |  | 233,636.08 | 02.03.01 |
| 129 | 1.3.3.1.1 | **EXCAVACION DE ZANJAS** | 20d | 2022-08-06 | 2022-08-25 |  | 0d |  | 18,371.28 | 02.03.01.01 |
| 130 | 1.3.3.1.1.1 | EXCAVACIONES EN TERRENO NATURAL CON MAQUINA P/BUZÓN | 20d | 2022-08-06 | 2022-08-25 | 62SS+1d | 0d |  | 820.98 | 02.03.01.01.01 |
| 131 | 1.3.3.1.1.2 | EXCAV. ZANJA(MÁQ)P/TUB DN 200-250MM DE 2,01 M A 2,50 M PROF. | 20d | 2022-08-06 | 2022-08-25 | 130SS | 0d |  | 4,182.41 | 02.03.01.01.02 |
| 132 | 1.3.3.1.1.3 | EXCAV. ZANJA(MÁQ)P/TUB DN 200-250MM DE 2,51 M A 3,00 M PROF. | 20d | 2022-08-06 | 2022-08-25 | 131SS | 0d |  | 7,387.55 | 02.03.01.01.03 |
| 133 | 1.3.3.1.1.4 | EXCAV. ZANJA(MÁQ)P/TUB DN 200-250MM DE 3,01 M A 3,50 M PROF. | 20d | 2022-08-06 | 2022-08-25 | 132SS | 0d |  | 2,293.12 | 02.03.01.01.04 |
| 134 | 1.3.3.1.1.5 | EXCAV. ZANJA(MÁQ)P/TUB DN 200-250MM DE 3,51 M A 4.00 M PROF. | 20d | 2022-08-06 | 2022-08-25 | 133SS | 0d |  | 3,373.3 | 02.03.01.01.05 |
| 135 | 1.3.3.1.1.6 | EXCAV. ZANJA(MÁQ)P/TUB DN 200-250MM DE 4.01 M A 4.50 M PROF. | 20d | 2022-08-06 | 2022-08-25 | 134SS | 0d |  | 313.92 | 02.03.01.01.06 |

| ID | WBS | Task | Duration | Start | Finish | Predecessors | Total slack | Free slack | Cost | Text1 |
| --- | --- | --- | --- | --- | --- | --- | --- | --- | --- | --- |
| 136 | 1.3.3.1.2 | **REFINE Y CONFORMACIÓN DE ZANJAS** | 20d | 2022-08-08 | 2022-08-27 |  | 0d |  | 8,681.23 | 02.03.01.02 |
| 137 | 1.3.3.1.2.1 | REFINE Y NIVEL DE ZANJA P/TUB. DN 200 - 250MM PARA TODA PROF. | 20d | 2022-08-08 | 2022-08-27 | 135SS+2d | 0d |  | 1,862.63 | 02.03.01.02.01 |
| 138 | 1.3.3.1.2.2 | DRENAJE DE ZANJAS C/BOMBEO P/DEPRIMIR NAPA FREÁTICA | 20d | 2022-08-08 | 2022-08-27 | 137SS | 0d |  | 6,818.6 | 02.03.01.02.02 |
| 139 | 1.3.3.1.3 | **ENTIBADO DE ZANJAS** | 20d | 2022-08-08 | 2022-08-27 |  | 0d |  | 34,189.03 | 02.03.01.03 |
| 140 | 1.3.3.1.3.1 | ENTIBADO DE ZANJA DE 2.01 HASTA 2.50 m | 20d | 2022-08-08 | 2022-08-27 | 138SS | 0d |  | 8,319.97 | 02.03.01.03.01 |
| 141 | 1.3.3.1.3.2 | ENTIBADO DE ZANJA DE 2.51 HASTA 3.00 m | 20d | 2022-08-08 | 2022-08-27 | 140SS | 0d |  | 12,875.03 | 02.03.01.03.02 |
| 142 | 1.3.3.1.3.3 | ENTIBADO DE ZANJA DE 3.01 HASTA 3.50 m | 20d | 2022-08-08 | 2022-08-27 | 141SS | 0d |  | 4,932.16 | 02.03.01.03.03 |
| 143 | 1.3.3.1.3.4 | ENTIBADO DE ZANJA DE 3.51 HASTA 4.00 m | 20d | 2022-08-08 | 2022-08-27 | 142SS | 0d |  | 7,392.7 | 02.03.01.03.04 |
| 144 | 1.3.3.1.3.5 | ENTIBADO DE ZANJA DE 4.01 HASTA 4.50 M | 20d | 2022-08-08 | 2022-08-27 | 143SS | 0d |  | 669.17 | 02.03.01.03.05 |
| 145 | 1.3.3.1.4 | **CAMA DE APOYO PARA PROTECCION DE TUBERIAS** | 69d | 2022-08-18 | 2022-10-25 |  | 0d |  | 46,449.51 | 02.03.01.04 |
| 146 | 1.3.3.1.4.1 | CAMA DE OVER E=0.30 P/COL. SECUNDARIO DN 200-250mm | 15d | 2022-08-18 | 2022-09-01 | 144FS-10d | 0d |  | 12,765.32 | 02.03.01.04.01 |
| 147 | 1.3.3.1.4.2 | CAPA DE HORMIGÓN E=0.20 P/COL.SECUNDARIO DN 200-250MM | 15d | 2022-08-18 | 2022-09-01 | 146SS | 0d |  | 6,731.7 | 02.03.01.04.02 |
| 148 | 1.3.3.1.4.3 | CAMA DE ARENA E=0.10M. ZANJA P/TUB DN 200-250mm. | 15d | 2022-08-23 | 2022-09-06 | 147FS-10d | 0d |  | 4,489.66 | 02.03.01.04.03 |
| 149 | 1.3.3.1.4.4 | CAMA DE ARENA E=0.30m Sct P/Tubería DN 200-250mm | 10d | 2022-10-16 | 2022-10-25 | 166FS-3d | 34d |  | 22,462.83 | 02.03.01.04.04 |
| 150 | 1.3.3.1.5 | **RELLENO, APISONADO Y COMPACTACION ZANJAS** | 15d | 2022-10-16 | 2022-10-30 |  | 0d |  | 79,017.77 | 02.03.01.05 |
| 151 | 1.3.3.1.5.1 | RELLENO C/MATERIAL DE PRESTAMO DN 200-250MM DE 2,01 M A 2,50 M PROF. | 15d | 2022-10-16 | 2022-10-30 | 166SS+2d | 0d |  | 17,926.06 | 02.03.01.05.01 |
| 152 | 1.3.3.1.5.2 | RELLENO C/MATERIAL DE PRÉSTAMO DN 200-250MM DE 2,51 M A 3,00 M PROF. | 15d | 2022-10-16 | 2022-10-30 | 151SS | 0d |  | 33,185.57 | 02.03.01.05.02 |
| 153 | 1.3.3.1.5.3 | RELLENO C/MATERIAL DE PRÉSTAMO DN 200-250MM DE 3,01 M A 3,50 M PROF. | 15d | 2022-10-16 | 2022-10-30 | 152SS | 0d |  | 10,525.99 | 02.03.01.05.03 |
| 154 | 1.3.3.1.5.4 | RELLENO C/MATERIAL DE PRÉSTAMO DN 200-250MM DE 3,51 M A 4.00 M PROF. | 15d | 2022-10-16 | 2022-10-30 | 153SS | 0d |  | 15,885.8 | 02.03.01.05.04 |
| 155 | 1.3.3.1.5.5 | RELLENO C/MATERIAL DE PRÉSTAMO DN 200-250MM DE 4.01 M A 4.50 M PROF. | 15d | 2022-10-16 | 2022-10-30 | 154SS | 0d |  | 1,494.35 | 02.03.01.05.05 |
| 156 | 1.3.3.1.6 | **ACARREO Y ELIMINACION MATERIAL EXCEDENTE** | 12d | 2022-08-18 | 2022-08-29 |  | 91d |  | 46,927.26 | 02.03.01.06 |
| 157 | 1.3.3.1.6.1 | ACARREO INTERNO, MATERIAL PROCEDEDENTE DE LAS EXCAVACIONES EN ZONA ALEDAÑA | 12d | 2022-08-18 | 2022-08-29 | 135FS-8d | 91d | 0d | 22,961.58 | 02.03.01.06.01 |
| 158 | 1.3.3.1.6.2 | ELIMINACIÓN DE MATERIAL EXCEDENTE D. PROM 5 KM DE LA OBRA | 12d | 2022-08-18 | 2022-08-29 | 157SS | 91d |  | 23,965.68 | 02.03.01.06.02 |
| 159 | 1.3.3.2 | **SUMINISTRO E INSTALACION DE TUBERIA** | 35d | 2022-08-25 | 2022-09-28 |  | 0d |  | 34,458 | 02.03.02 |
| 160 | 1.3.3.2.1 | TUBERÍA PVC-U SC NTP ISO 4435 SN4 DN 200MM INCL. ANILLO + 2% DESPERDICIOS | 35d | 2022-08-25 | 2022-09-28 | 148SS+2d | 0d |  | 14,587.28 | 02.03.02.01 |
| 161 | 1.3.3.2.2 | TUBERÍA PVC-U SC NTP ISO 4435 SN4 DN 250MM INCL. ANILLO + 2% DESPERDICIOS | 35d | 2022-08-25 | 2022-09-28 | 160SS | 0d |  | 17,528 | 02.03.02.02 |
| 162 | 1.3.3.2.3 | INSTALACIÓN DE TUBERÍA DE PVC P/DESAGÜE DN 200mm | 35d | 2022-08-25 | 2022-09-28 | 161SS | 0d |  | 1,364.3 | 02.03.02.03 |
| 163 | 1.3.3.2.4 | INSTALACIÓN DE TUBERÍA DE PVC P/DESAGÜE DN 250mm. | 35d | 2022-08-25 | 2022-09-28 | 162SS | 0d |  | 978.42 | 02.03.02.04 |

| ID | WBS | Task | Type | Duration | Start | Finish | Predecessors | Total slack | Free slack | Constraint | Cost | Text1 |
| --- | --- | --- | --- | --- | --- | --- | --- | --- | --- | --- | --- | --- |
| 164 | 1.3.3.3 | **PRUEBAS HIDRAULICAS** |  | 5d | 2022-10-14 | 2022-10-18 |  | 0d |  |  | 8,055.26 | 02.03.03 |
| 165 | 1.3.3.3.1 | PRUEBA HIDRÁULICA DE TUBERÍA P/DESAGÜE PVC-UF NTP ISO 4435, SN 4 DN 200 MM |  | 5d | 2022-10-14 | 2022-10-18 | 177SS | 0d |  |  | 4,611.39 | 02.03.03.01 |
| 166 | 1.3.3.3.2 | PRUEBA HIDRÁULICA DE TUBERÍA P/DESAGÜE PVC-UF NTP ISO 4435, SN 4 DN 250 MM |  | 5d | 2022-10-14 | 2022-10-18 | 165SS | 0d |  |  | 3,443.87 | 02.03.03.02 |
| 167 | 1.3.3.4 | **CAMARAS DE INSPECCION (BUZONES)** |  | 35d | 2022-09-14 | 2022-10-18 |  | 0d |  |  | 49,318.38 | 02.03.04 |
| 168 | 1.3.3.4.1 | BUZÓN TIPO I Di=1.2m. HASTA 1,50 m PROF.(ENCOF.EXTER.E INTER) |  | 35d | 2022-09-14 | 2022-10-18 | 163FS-15d | 0d |  |  | 3,593.35 | 02.03.04.01 |
| 169 | 1.3.3.4.2 | BUZÓN TIPO I Di=1.2m. HASTA 2,00 m PROF.(ENCOF.EXTER.E INTER) |  | 35d | 2022-09-14 | 2022-10-18 | 168SS | 0d |  |  | 17,311.96 | 02.03.04.02 |
| 170 | 1.3.3.4.3 | BUZÓN TIPO I Di=1.2m. HASTA 2,50 m PROF.(ENCOF.EXTER.E INTER) |  | 35d | 2022-09-14 | 2022-10-18 | 169SS | 0d |  |  | 4,913.65 | 02.03.04.03 |
| 171 | 1.3.3.4.4 | BUZÓN TIPO I Di=1.2m. HASTA 3,00 m PROF.(ENCOF.EXTER.E INTER) |  | 35d | 2022-09-14 | 2022-10-18 | 170SS | 0d |  |  | 6,106.42 | 02.03.04.04 |
| 172 | 1.3.3.4.5 | BUZÓN TIPO I DI=1.2M. HASTA 4,50 M PROF. (ENCOF.EXTER.E INTER) |  | 35d | 2022-09-14 | 2022-10-18 | 171SS | 0d |  |  | 17,393 | 02.03.04.05 |
| 173 | 1.3.3.5 | **DADO DE ANCLAJE** |  | 35d | 2022-09-14 | 2022-10-18 |  | 0d |  |  | 1,206.19 | 02.03.05 |
| 174 | 1.3.3.5.1 | CONCRETO F'C 140 kg/cm2 PARA ANCLAJES Y/O DADOS (CEMENTO MS) |  | 35d | 2022-09-14 | 2022-10-18 | 172SS | 0d |  |  | 1,206.19 | 02.03.05.01 |
| 175 | 1.3.3.6 | **CONEXIONES DOMICILIARIAS DE DESAGUE** |  | 5d | 2022-10-14 | 2022-10-18 |  | 0d |  |  | 54,051.54 | 02.03.06 |
| 176 | 1.3.3.6.1 | CONEXIONES DOMICILIARIAS PARA DESAGÜE DN 200x160mm |  | 5d | 2022-10-14 | 2022-10-18 | 174FS-5d | 0d |  |  | 36,005.19 | 02.03.06.01 |
| 177 | 1.3.3.6.2 | CONEXIONES DOMICILIARIAS PARA DESAGÜE DN 250X160MM |  | 5d | 2022-10-14 | 2022-10-18 | 176SS | 0d |  |  | 18,046.35 | 02.03.06.02 |
| 178 | 1.3.3.7 | **RETIRO Y REPOSICION DE CONEXION DOMICILIARIA DE ALCANTARILLADO** |  | 29d | 2022-10-04 | 2022-11-01 |  | 14d |  |  | 14,968.8 | 02.03.07 |
| 179 | 1.3.3.7.1 | CORTE DE VEREDA P/CONEXIÓN DOMICILIARIA |  | 12d | 2022-10-04 | 2022-10-15 | 176SS-10d | 44d | 0d |  | 3,451.68 | 02.03.07.01 |
| 180 | 1.3.3.7.2 | DEMOLICIÓN DE VEREDA P/CONEXIÓN DOMICILIARIA |  | 12d | 2022-10-04 | 2022-10-15 | 179SS | 44d | 0d |  | 1,045.44 | 02.03.07.02 |
| 181 | 1.3.3.7.3 | RETIRO DE CAJA DOMICILIARIA EXISTENTE (TAPA, CUERPO Y BASAE) |  | 12d | 2022-10-04 | 2022-10-15 | 180SS | 44d |  |  | 3,312 | 02.03.07.03 |
| 182 | 1.3.3.7.4 | CONCRETO F'C 175 kg/cm2 PARA VEREDAS E=10cm. (CEMENTO MS) |  | 15d | 2022-10-18 | 2022-11-01 | 155FS-13d | 0d |  |  | 7,159.68 | 02.03.07.04 |
| 183 | 1.3.3.8 | **EMPALMES A BUZON DE SERVICIO Y OTROS** |  | 55d | 2022-08-05 | 2022-09-28 |  | 61d |  |  | 19,746.06 | 02.03.08 |
| 184 | 1.3.3.8.1 | EMPALMES DE TUBERÍAS DN 200/250MM A BUZÓN EXISTENTE EN SERVICIO |  | 35d | 2022-08-25 | 2022-09-28 | 163SS | 61d |  |  | 3,748.3 | 02.03.08.01 |
| 185 | 1.3.3.8.2 | DEMOLICIÓN DE BUZONES EXISTENTES |  | 35d | 2022-08-06 | 2022-09-09 | 135SS | 80d |  |  | 4,330.59 | 02.03.08.02 |
| 186 | 1.3.3.8.3 | TRANSPORTE DE MATERIALES A OBRA |  | 15d | 2022-08-05 | 2022-08-19 | 57SS | 101d |  |  | 11,667.17 | 02.03.08.03 |
| 187 | 1.4 | FIN DEL PROYECTO | milestone | 0d | 2022-11-28 | 2022-11-28 | 52 | 0d |  | as late as possible |  |  |
